# Superv.Carret.Ayacu.

Schedule from MS Project, 2009-09-07 to 2011-02-28.
Lagesa Ingenieros Consultores

## Calendars

- Estándar: Mon-Sun 08:00-12:00, 13:00-17:00.

## Resources

| Resource | Rate | Cost per use |
| --- | --- | --- |
| JEFE DE PROYECTO | 102.17 | 8400 |
| ING VIAL | 76.63 | 4800 |
| ING GEOTECNIA | 76.63 | 4800 |
| ING GEOLOGIA | 76.63 | 2400 |
| ING HIDROLOGO | 76.63 | 2400 |
| ESP AMBIENTAL | 76.63 | 3600 |
| TOPOGRAFO | 31.93 | 4200 |
| NIVELADOR | 25.54 | 3680 |
| EQUIPO TOPGRAFICO | 76.92 |  |
| UTILES TOPOGRAFICOS | 4.81 |  |
| SECCIONISTAS | 22.99 |  |
| AYUDANTE DE TOPOGRAFIA | 11.49 |  |
| ALQ. VEHICULOS | 42.91 |  |
| TECNICO DE SUELOS | 31.93 | 3680 |
| AYUDANTES DE SUELOS | 11.49 |  |
| ING ESPEC. TRAFICO | 76.63 | 1800 |
| AYUDANTE DE EST. TRAFICO | 15.33 |  |
| ENCUESTADOR DE TRAFICO | 15.33 |  |
| ING. ESTRUCTURAL | 76.63 | 3000 |
| ING ASISTENTE | 38.31 | 3900 |
| ING SEÑALIZACION Y SEG. VIAL | 76.63 | 1800 |
| ING COSTOS Y PRESUPUESTOS | 76.63 |  |

## Schedule

| ID | WBS | Task | Duration | Start | Finish | Predecessors | Baseline start | Baseline finish | Baseline duration | Total slack | Free slack | Constraint | Text1 |
| --- | --- | --- | --- | --- | --- | --- | --- | --- | --- | --- | --- | --- | --- |
| 1 | 1 | **INICIO** | 540d | 2009-09-07 | 2011-02-28 |  |  |  |  | 0d |  |  |  |
| 2 | 1.1 | **Preliminares** | 540d | 2009-09-07 | 2011-02-28 |  | 1998-08-01 | 1998-08-10 | 8d | 0d |  |  | 100 |
| 3 | 1.1.1 | Movilización de equipos | 90d | 2009-09-07 | 2009-12-05 |  |  |  |  | 0d |  | start no earlier than 2009-09-07 | 101.A |
| 4 | 1.1.2 | Desmovilización de equipos | 60d | 2010-12-31 | 2011-02-28 | 3FS+390d |  |  |  | 0d |  | start no earlier than 2002-02-01 |  |
| 5 | 1.1.3 | Topografía y georeferenciacion | 60d | 2009-09-07 | 2009-11-05 |  |  |  |  | 480d |  | start no earlier than 2009-09-07 | 102.B |
| 6 | 1.1.4 | Mantenimiento de tránsito | 539d | 2009-09-07 | 2011-02-27 | 3SS |  |  |  | 1d |  |  | 103.A |
| 7 | 1.2 | **Movimiento de tierras** | 510d | 2009-09-07 | 2011-01-29 |  | 1998-08-01 | 1998-08-10 | 8d | 20d |  |  | 200 |
| 8 | 1.2.1 | Desbroce y limpieza en zonas boscosas | 120d | 2009-09-07 | 2010-01-04 |  |  |  |  | 420d |  | start no earlier than 2009-09-07 | 201.A |
| 9 | 1.2.2 | Demolición de estructuras | 60d | 2009-09-17 | 2009-11-15 | 3SS+10d | 1998-08-11 | 1999-01-11 | 132d | 470d |  | start no earlier than 2008-11-17 | 202.A |
| 10 | 1.2.3 | Excavación de explanaciones en roca fija | 270d | 2009-09-27 | 2010-06-23 | 3SS+20d |  |  |  | 250d |  |  | 205.B |
| 11 | 1.2.4 | Excavación de explanaciones en roca suelta | 270d | 2009-09-27 | 2010-06-23 | 3SS+20d |  |  |  | 250d |  |  | 205.C |
| 12 | 1.2.5 | Excavación de explanaciones en material comun | 270d | 2009-09-27 | 2010-06-23 | 3SS+20d | 1998-08-11 | 1998-12-10 | 105d | 0d |  | start no earlier than 2001-05-18 | 205.D |
| 13 | 1.2.6 | Remoción de derrumbes | 510d | 2009-09-07 | 2011-01-29 | 3SS |  |  |  | 30d |  | start no earlier than 2001-05-01 | 206.A |
| 14 | 1.2.7 | Terraplenes | 270d | 2009-09-27 | 2010-06-23 | 12SS |  |  |  | 0d |  | start no earlier than 2001-12-21 | 210.A |
| 15 | 1.2.8 | Compactación y perfilado en zonas de corte | 150d | 2009-10-07 | 2010-03-05 | 12SS+10d |  |  |  | 210d | 0d | start no earlier than 2001-05-18 | 225.A |
| 16 | 1.2.9 | Sobre excavación | 120d | 2010-06-24 | 2010-10-21 | 12 |  |  |  | 130d |  |  | 211 |
| 17 | 1.3 | **Sub bases y Bases** | 265d | 2010-02-24 | 2010-11-15 |  |  |  |  | 0d |  |  | 300 |
| 18 | 1.3.1 | Sub base | 205d | 2010-02-24 | 2010-09-16 | 14FS-120d |  |  |  | 0d |  |  | 303.A |
| 19 | 1.3.2 | Base granular | 210d | 2010-04-20 | 2010-11-15 | 18FS-150d |  |  |  | 0d |  | start no earlier than 2001-09-01 | 305.A |
| 20 | 1.4 | **Pavimento asfáltico** | 165d | 2010-08-03 | 2011-01-14 |  |  |  |  | 35d |  |  | 400 |
| 21 | 1.4.1 | Imprimación asfáltica | 100d | 2010-08-03 | 2010-11-10 | 19FS-105d |  |  |  | 35d | 0d | start no earlier than 2001-11-08 | 401.A |
| 22 | 1.4.2 | Pavimento de concreto asfáltico | 120d | 2010-09-17 | 2011-01-14 | 19FS-60d, 21SS+10d |  |  |  | 0d |  | start no earlier than 2001-11-08 | 410.B |
| 23 | 1.4.3 | Tratamiento superficial bicapa | 15d | 2010-12-26 | 2011-01-09 | 22SS+100d |  |  |  | 50d |  |  | 405 |
| 24 | 1.4.4 | Cemento asfáltico Pen 60-70 | 120d | 2010-09-17 | 2011-01-14 | 22SS |  |  |  | 45d |  | start no earlier than 2001-11-08 | 420 |
| 25 | 1.4.5 | Asfalto diluído MC-30 | 100d | 2010-08-03 | 2010-11-10 | 21SS |  |  |  | 110d |  | start no earlier than 2001-10-19 | 422 |
| 26 | 1.4.6 | Filler mineral (cal hidratada) | 120d | 2010-09-17 | 2011-01-14 | 22SS |  |  |  | 45d |  | start no earlier than 2001-11-08 | 425 |
| 27 | 1.4.7 | Mejorador de adherencia | 120d | 2010-08-03 | 2010-11-30 | 21SS |  |  |  | 90d |  | start no earlier than 2001-11-08 | 423 |

| ID | WBS | Task | Duration | Start | Finish | Predecessors | Total slack | Free slack | Constraint | Text1 |
| --- | --- | --- | --- | --- | --- | --- | --- | --- | --- | --- |
| 28 | 1.5 | **Obras de arte y drenaje** | 332d | 2009-10-17 | 2010-09-13 |  | 123d |  |  | 600 |
| 29 | 1.5.1 | Excavación para estructuras en material común en seco | 135d | 2009-10-17 | 2010-02-28 | 12SS+20d | 123d | 0d | start no earlier than 2001-07-02 | 601.C |
| 30 | 1.5.2 | Relleno para estructuras | 135d | 2009-11-11 | 2010-03-25 | 29SS+25d | 340d |  | start no earlier than 2001-09-01 | 602.A |
| 31 | 1.5.3 | Concreto reforzado 210 kg/cm2 | 150d | 2010-04-17 | 2010-09-13 | 32SS+25d, 36, 35 | 123d | 0d | start no earlier than 2001-08-01 | 610.C |
| 32 | 1.5.4 | Concreto simple 175 kg/cm2 | 157d | 2009-11-01 | 2010-04-06 | 29SS, 35SS | 123d | 0d | start no earlier than 2001-07-02 | 610-B |
| 33 | 1.5.5 | Concreto simple 100 kg/cm2 | 157d | 2009-10-17 | 2010-03-22 | 29SS | 343d |  | start no earlier than 2001-07-02 | 610-A |
| 34 | 1.5.6 | Concreto ciclópeo 175 kg/ cm2+30% P.G. | 147d | 2009-11-01 | 2010-03-27 | 29SS+10d, 35SS | 293d | 170d | start no earlier than 2001-07-13 | 610-E |
| 35 | 1.5.7 | Encofrados | 165d | 2009-11-01 | 2010-04-14 | 29SS+15d | 123d | 0d |  | 612 |
| 36 | 1.5.8 | Acero de refuerzo | 167d | 2009-11-01 | 2010-04-16 | 32SS, 35SS | 123d | 0d | start no earlier than 2001-07-02 | 615 |
| 37 | 1.5.9 | Alcantarilla TMC Diam 36" | 68d | 2010-03-01 | 2010-05-07 | 29 | 297d | 0d | start no earlier than 2001-07-02 | 622.B |
| 38 | 1.5.10 | Alcantarilla TMC Diam 48" | 68d | 2010-03-01 | 2010-05-07 | 29 | 297d |  | start no earlier than 2001-07-02 | 622.C |
| 39 | 1.5.11 | Alcantarilla TMC Diam 60" | 45d | 2010-03-24 | 2010-05-07 | 29, 37FF | 297d |  |  | 622.D |
| 40 | 1.6 | **Transporte** | 465d | 2009-10-07 | 2011-01-14 |  | 45d |  |  | 700 |
| 41 | 1.6.1 | Transporte de material granular hasta 1 Km | 270d | 2010-04-20 | 2011-01-14 | 19SS, 18SS | 45d |  | start no earlier than 2001-06-01 | 700.A |
| 42 | 1.6.2 | Transporte de material granular a mas de 1 Km | 270d | 2010-04-20 | 2011-01-14 | 19SS | 45d |  | start no earlier than 2001-06-01 | 700.B |
| 43 | 1.6.3 | Transporte de escombros hasta 1.00 Km | 300d | 2009-10-07 | 2010-08-02 | 12SS, 13SS, 15SS | 210d |  | start no earlier than 2001-09-01 | 700.C |
| 44 | 1.6.4 | Transporte de escombros a mas de 1.00 Km | 300d | 2009-10-07 | 2010-08-02 | 12SS, 13SS, 15SS | 210d |  | start no earlier than 2001-09-01 | 700.D |
| 45 | 1.6.5 | Transporte de mezcla asfáltica hasta 1.00 Km | 120d | 2010-09-17 | 2011-01-14 | 22SS | 45d |  | start no earlier than 2001-11-09 | 700.E |
| 46 | 1.6.6 | Transporte de mezcla asfáltica a mas de 1.00 Km | 120d | 2010-09-17 | 2011-01-14 | 22SS | 45d |  | start no earlier than 2001-11-09 | 700.F |
| 47 | 1.7 | **Señalización y Seguridad Vial** | 168d | 2010-09-14 | 2011-02-28 |  | 0d |  |  | 800 |
| 48 | 1.7.1 | Señales preventivas de 0.75 m x 0.75 m | 45d | 2011-01-15 | 2011-02-28 | 22 | 0d |  | start no earlier than 2002-02-01 | 801 |
| 49 | 1.7.2 | Señales reglamentarias de 0.75 m x 0.75 m | 45d | 2011-01-15 | 2011-02-28 | 22 | 0d |  | start no earlier than 2002-02-01 | 802 |
| 50 | 1.7.3 | Señales informativas | 45d | 2011-01-15 | 2011-02-28 | 22 | 0d |  | start no earlier than 2002-02-01 | 803 |
| 51 | 1.7.4 | Poste de soporte de señales | 45d | 2011-01-15 | 2011-02-28 | 48SS, 49SS, 50SS | 0d |  | start no earlier than 2002-01-01 | 804.A |
| 52 | 1.7.5 | Estructura de soporte de señales | 45d | 2011-01-15 | 2011-02-28 | 49SS, 48SS, 50SS | 0d |  | start no earlier than 2002-01-01 | 804.B |
| 53 | 1.7.6 | Marcas retroreflexivas con pintura de tránsito convencional | 45d | 2011-01-15 | 2011-02-28 | 22 | 0d |  | start no earlier than 2002-01-19 | 810 |
| 54 | 1.7.7 | Guardavías metálicas | 45d | 2011-01-15 | 2011-02-28 | 22 | 0d |  | start no earlier than 2002-01-01 | 820.A |
| 55 | 1.7.8 | Poste de kilometraje | 45d | 2011-01-15 | 2011-02-28 | 22 | 0d |  | start no earlier than 2002-03-01 | 830 |
| 56 | 1.7.9 | Gibas | 45d | 2010-09-14 | 2010-10-28 | 31, 32, 34 | 123d | 0d |  | 813 |
| 57 | 1.7.10 | Resonadores | 45d | 2010-09-14 | 2010-10-28 | 56SS | 123d |  |  |  |

| ID | WBS | Task | Type | Duration | Start | Finish | Predecessors | Total slack | Free slack | Constraint | Text1 |
| --- | --- | --- | --- | --- | --- | --- | --- | --- | --- | --- | --- |
| 58 | 1.8 | **Protección ambiental** |  | 539d | 2009-09-07 | 2011-02-27 |  | 1d |  |  | 900 |
| 59 | 1.8.1 | Medidas de Protección Ambiental |  | 539d | 2009-09-07 | 2011-02-27 | 3SS | 1d |  | start no earlier than 2001-12-01 | 901 |
| 60 | 1.9 | **Puentes - Construcción** |  | 490d | 2009-10-02 | 2011-02-03 |  | 25d |  |  | 1000 |
| 61 | 1.9.1 | Movimiento de tierras |  | 100d | 2009-10-02 | 2010-01-09 | 3SS+25d | 25d | 0d |  | 1001 |
| 62 | 1.9.2 | Estribos |  | 210d | 2010-01-10 | 2010-08-07 | 61 | 25d | 0d |  | 1002 |
| 63 | 1.9.3 | Superestructura |  | 150d | 2010-08-08 | 2011-01-04 | 62 | 25d | 0d |  | 1003 |
| 64 | 1.9.4 | Varios |  | 30d | 2011-01-05 | 2011-02-03 | 63 | 25d |  |  | 1006 |
| 65 | 2 | FIN | milestone | 0d | 2011-02-28 | 2011-02-28 | 4, 5, 6, 59, 9, 12, 13, 14, 15, 16, 19, 21, 22, 24, 25, 26, 27, 29, 30, 31, 32, 33, 34, 35, 36, 37, 38, 41, 42, 43, 44, 45, 46, 48, 49, 50, 51, 52, 53, 55, 56, 61, 62, 63, 64, 54 | 0d |  |  |  |
